# Cronograma Huarmey PA

Schedule from MS Project, 2023-06-01 to 2024-08-08.

## Calendars

- Estándar: Mon-Sat 09:00-13:00, 15:00-19:00; Sun off. Exceptions (off unless hours are given): 2023-06-29 (San Pedro y San Pablo 2023), 2023-07-28 to 2023-07-29 (Fiestas Patrias), 2023-08-30 (Santa Rosa de Lima), 2023-11-01 (Dia de los Santos), 2023-12-23 to 2023-12-25 (Navidad), 2023-12-30 to 2024-01-01 (Año Nuevo), 2024-03-28 to 2024-03-31 (Semana Santa 2024), 2024-05-01 (Dia del Trabajo 2024), 2024-06-29 (San Pedro y San Pablo 2024), 2024-07-28 to 2024-07-30 (Fiestas Patrias 2024).

## Resources

| Resource |
| --- |
| Cargador Frontal L 150G |
| Excavadora Hyundai con picoton |
| Excavadora EC 380DL |
| Excavadora Cat 360 (Uña Roquera) |
| Cargador Frontal L 150G |
| Cargador Frontal L 120F |
| Motoniveladora de 140 HP |
| Rodillo Liso Vibratorio Autopropulsado 10-12 Tn |
| Volquetes de 6x4 |

## Schedule

| ID | WBS | Task | Type | Duration | Start | Finish | Predecessors | Total slack | Free slack | Constraint | Dias Calendario | Metrado | Unidad | Frentes | Duracion | Rendimiento diario |
| --- | --- | --- | --- | --- | --- | --- | --- | --- | --- | --- | --- | --- | --- | --- | --- | --- |
| 1 | 1 | **DEFENSAS RIBEREÑAS P2 RÍO HUARMEY SECTOR 2 PARTE BAJA** |  | 356d | 2023-06-01 | 2024-08-08 |  | 0d |  |  | 435 días |  |  |  |  |  |
| 2 | 1.1 | INICIO DE OBRA | milestone | 0d | 2023-06-01 | 2023-06-01 |  | 0d |  | finish no earlier than 2023-06-01 | 0 días |  |  |  |  |  |
| 3 | 1.2 | **OBRAS PROVISIONALES** |  | 15d | 2023-06-02 | 2023-06-19 |  | 0d |  |  | 1 días |  |  |  |  |  |
| 4 | 1.2.1 | CARTEL DE IDENTIFICACION DE LA OBRA DE 3.60M X 2.40M. |  | 3d | 2023-06-02 | 2023-06-05 | 2 | 353d |  |  | 4 días | 1.00 | und |  |  |  |
| 5 | 1.2.2 | INSTALACIÓN DE FACILIDADES Y CAMPAMENTOS |  | 15d | 2023-06-02 | 2023-06-19 | 2 | 0d |  |  | 18 días | 1.00 | glb |  |  |  |
| 6 | 1.3 | **OBRAS PRELIMINARES** |  | 356d | 2023-06-02 | 2024-08-08 |  | 0d |  |  | 1 días |  |  |  |  |  |
| 7 | 1.3.1 | MOVILIZACIÓN Y DESMOVILIZACIÓN DE EQUIPOS Y/O MAQUINARIA |  | 43d | 2023-06-02 | 2024-08-08 | 5SS | 0d |  |  | 434 días | 1.00 | glb |  |  |  |
| 8 | 1.3.2 | TRAZO, NIVELACION Y REPLANTEO PRELIMINAR |  | 30d | 2023-06-02 | 2023-07-07 | 7SS | 0d |  |  | 36 días | 28.87 | Km |  |  |  |
| 9 | 1.3.3 | CONTROL TOPOGRAFICO DURANTE LA EJECUCIÓN |  | 263d | 2023-06-02 | 2024-08-08 | 8SS | 0d |  |  | 434 días | 14.00 | mes |  |  |  |
| 10 | 1.3.4 | HABILITACIÓN DE ACCESOS |  | 15d | 2023-06-08 | 2023-06-24 | 8SS+5d | 21d | 0d |  | 17 días | 11.81 | km | 1.00 | 9.21 |  |
| 11 | 1.3.5 | DESVÍO Y MANEJO DE AGUAS SUPERFICIALES |  | 15d | 2023-06-10 | 2023-06-27 | 10SS+2d | 21d | 0d |  | 18 días | 8,640.00 | m3 | 1.00 | 8.02 | 1,077 |
| 12 | 1.3.6 | MANTENIMIENTO DE TRÁNSITO Y SEGURIDAD VIAL EN ACCESOS A LA OBRA Y ÁREAS AUXILIARES (Canteras, DME/DMO, Fuentes de agua) |  | 263d | 2023-06-02 | 2024-08-08 | 8SS | 0d |  |  | 434 días | 14.00 | mes |  |  |  |
| 13 | 1.4 | **OPERACIÓN Y EXPLOTACION DE MATERIAL** |  | 314d | 2023-06-28 | 2024-07-13 |  | 20d |  |  | 1 días |  |  |  |  |  |
| 14 | 1.4.1 | EXPLOTACION Y PREPARACION DE MATERIAL PARA CONFORMACION DE DIQUE |  | 190d | 2023-06-28 | 2024-06-05 | 11 | 21d | 0d |  | 344 días | 145,612.52 | m3 | 1.00 | 187.22 | 778 |
| 15 | 1.4.2 | EXPLOTACION Y PREPARACION DE MATERIAL PARA AFIRMADO |  | 55d | 2023-08-05 | 2023-10-09 | 14SS+30d | 249d |  |  | 66 días | 28,644.77 | m3 | 1.00 | 50.22 | 570 |
| 16 | 1.4.3 | PREPARACIÓN DE MATERIAL PROPIO |  | 220d | 2023-07-03 | 2024-07-13 | 20SS+5d | 20d |  |  | 377 días | 426,628.81 | m3 | 2.00 | 257.12 | 830 |
| 17 | 1.5 | **MOVIMIENTO DE TIERRAS** |  | 341d | 2023-06-20 | 2024-08-08 |  | 0d |  |  | 1 días |  |  |  |  |  |
| 18 | 1.5.1 | **CONSTRUCCIÓN DE DIQUE NUEVO** |  | 341d | 2023-06-20 | 2024-08-08 |  | 0d |  |  | 1 días |  |  |  |  |  |
| 19 | 1.5.1.1 | DESBROCE Y LIMPIEZA |  | 130d | 2023-06-20 | 2023-11-23 | 8SS+15d | 0d |  |  | 157 días | 29.09 | ha | 1.00 | 126.06 |  |
| 20 | 1.5.1.2 | EXCAVACIÓN MASIVA EN MATERIAL SUELTO, CON EQUIPO |  | 160d | 2023-06-26 | 2024-01-08 | 19SS+5d | 0d |  |  | 197 días | 168,704.10 | m3 | 1.00 | 156.65 | 1,077 |
| 21 | 1.5.1.3 | EXCAVACIÓN EN ROCA SUELTA CON EQUIPO |  | 15d | 2023-07-03 | 2023-07-19 | 20SS+5d | 316d | 0d |  | 17 días | 1,721.47 | m3 | 1.00 | 5.16 | 333 |
| 22 | 1.5.1.4 | EXCAVACIÓN DE ROCA FIJA CON MARTILLO HIDRÁULICO |  | 15d | 2023-07-03 | 2023-07-19 | 21SS | 316d |  |  | 17 días | 1,721.47 | m3 | 1.00 | 8.61 | 200 |
| 23 | 1.5.1.5 | EXCAVACION DE UÑA EN MATERIAL CON NIVEL FREATICO |  | 210d | 2023-07-08 | 2024-07-10 | 20SS+10d | 0d |  |  | 369 días | 235,965.98 | m3 | 3.00 | 227.23 | 346 |
| 24 | 1.5.1.6 | CONFORMACIÓN Y COMPACTACIÓN DE DIQUE |  | 220d | 2023-07-14 | 2024-07-27 | 31SS+5d | 2d | 0d |  | 380 días | 516,182.57 | m3 | 3.00 | 223.68 | 769 |
| 25 | 1.5.1.7 | ENROCADO Y ACOMODO DE ROCA PARA PROTECCIÓN DE TALUD TIPO 1 |  | 195d | 2023-08-11 | 2024-07-24 | 27SS+15d | 11d | 0d |  | 349 días | 46,969.63 | m3 | 2.00 | 251.62 | 93 |
| 26 | 1.5.1.8 | ENROCADO Y ACOMODO DE ROCA PARA PROTECCIÓN DE TALUD TIPO 2 |  | 205d | 2023-08-11 | 2024-08-07 | 28SS+15d | 0d |  |  | 363 días | 52,484.42 | m3 | 3.00 | 218.69 | 80 |
| 27 | 1.5.1.9 | ENROCADO Y ACOMODO DE ROCA EN UÑA ANTISOCAVANTE TIPO 1 |  | 175d | 2023-07-22 | 2024-06-12 | 23SS+12d | 0d |  |  | 327 días | 27,974.18 | m3 | 1.00 | 173.00 | 162 |
| 28 | 1.5.1.10 | ENROCADO Y ACOMODO DE ROCA EN UÑA ANTISOCAVANTE TIPO 2 |  | 220d | 2023-07-22 | 2024-08-07 | 27SS | 0d |  |  | 383 días | 47,202.54 | m3 | 1.00 | 268.48 | 176 |
| 29 | 1.5.1.11 | DESCOLMATACIÓN DEL CAUCE |  | 155d | 2023-06-28 | 2024-01-04 | 11 | 179d |  |  | 191 días | 190,764.72 | m3 | 1.00 | 155.00 | 1,231 |
| 30 | 1.5.1.12 | REFINE Y PERFILADO DE TALUD |  | 218d | 2023-07-20 | 2024-08-05 | 24SS+5d | 2d | 0d |  | 383 días | 101,555.27 | m2 | 1.00 | 211.23 | 481 |
| 31 | 1.5.1.13 | MEJORAMIENTO DE SUELO DE FUNDACIÓN |  | 45d | 2023-07-08 | 2023-09-01 | 20SS+10d | 2d | 0d |  | 56 días | 18,698.49 | m3 | 1.00 | 40.51 | 462 |
| 32 | 1.5.1.14 | ZANJA Y RELLENO PARA ANCLAJE DE GEOTEXTIL |  | 202d | 2023-07-20 | 2024-07-12 | 30SS | 21d |  | start no earlier than 2023-07-09 | 359 días | 11,810.00 | ml | 1.00 | 143.84 | 82 |
| 33 | 1.5.1.15 | GEOTEXTIL NO TEJIDO CLASE 1, INCLUYE INSTALACIÓN |  | 166d | 2023-07-21 | 2024-05-31 | 30SS+1d | 2d | 0d |  | 316 días | 140,560.59 | m2 | 1.00 | 200 | 700 |
| 34 | 1.5.1.16 | GEOTEXTIL NO TEJIDO CLASE 2, INCLUYE INSTALACIÓN |  | 220d | 2023-07-21 | 2024-08-06 | 33SS | 2d |  |  | 383 días | 123,308.87 | m2 |  | 200 | 700 |
| 35 | 1.5.1.17 | CONFORMACIÓN DE DME/DMO |  | 245d | 2023-06-20 | 2024-08-07 | 58SS | 1d |  |  | 415 días | 216,859.74 | m3-km | 1.00 | 156.62 | 1,385 |
| 36 | 1.5.1.18 | RELLENO COMPACTADO CON MATERIAL PARA AFIRMADO EN CORONA |  | 210d | 2023-08-05 | 2024-08-07 | 25SS-5d | 1d |  | start no earlier than 2023-07-30 | 369 días | 22,227.14 | m3 | 1.00 | 96.32 | 231 |
| 37 | 1.5.1.19 | RELLENO CON MATERIAL PROPIO |  | 85d | 2024-04-27 | 2024-08-08 | 28FF+1d | 0d |  |  | 104 días | 99,272.06 | m3 | 1.00 | 86.04 | 1,154 |
| 38 | 1.5.1.20 | TRATAMIENTO DE TALUD CON GEOCELDAS (INCLUYE RELLENO DE GRAVAS) |  | 85d | 2024-04-26 | 2024-08-07 | 28FF | 1d |  |  | 104 días | 28,231.97 | m2 | 1.00 | 80.66 | 350 |
| 39 | 1.5.1.21 | MURO ESCOLLERA |  | 80d | 2024-05-04 | 2024-08-08 | 26FF+1d | 0d |  |  | 97 días | 4,689.12 | m3 | 1.00 | 156.30 | 30 |

| ID | WBS | Task | Duration | Start | Finish | Predecessors | Total slack | Free slack | Constraint | Dias Calendario | Frentes | Metrado | Rendimiento diario | Unidad | Duracion |
| --- | --- | --- | --- | --- | --- | --- | --- | --- | --- | --- | --- | --- | --- | --- | --- |
| 40 | 1.5.2 | **REFUERZO EN DIQUES EXISTENTES** | 273d | 2023-09-08 | 2024-08-05 |  | 3d |  |  | 1 días |  |  |  |  |  |
| 41 | 1.5.2.1 | EXCAVACIÓN EN MATERIAL SUELTO, CON EQUIPO | 30d | 2023-09-08 | 2023-10-12 | 20SS+60d | 3d | 0d |  | 35 días | 1.00 | 30,087.19 | 1,077 | m3 | 27.94 |
| 42 | 1.5.2.2 | EXCAVACIÓN EN ROCA SUELTA CON EQUIPO | 5d | 2023-09-08 | 2023-09-13 | 41SS | 271d |  |  | 6 días | 1.00 | 303.91 | 333 | m3 | 0.91 |
| 43 | 1.5.2.3 | EXCAVACION DE UÑA EN MATERIAL CON NIVEL FREATICO | 150d | 2023-09-08 | 2024-06-27 | 41SS | 3d | 0d |  | 294 días | 1.00 | 29,645.13 | 346 | m3 | 85.64 |
| 44 | 1.5.2.4 | CONFORMACIÓN Y COMPACTACIÓN DE DIQUE | 10d | 2023-10-13 | 2023-10-24 | 43SS+30d | 3d | 0d |  | 12 días | 1.00 | 3,679.38 | 769 | m3 | 4.78 |
| 45 | 1.5.2.5 | ENROCADO Y ACOMODO DE ROCA EN TALUD DE DIQUE EXISTENTE | 120d | 2023-11-18 | 2024-08-05 | 46SS+15d | 3d |  |  | 262 días | 1.00 | 19,063.06 | 93 | m3 | 204.25 |
| 46 | 1.5.2.6 | ENROCADO Y ACOMODO DE ROCA EN UÑA DE DIQUE EXISTENTE | 120d | 2023-10-31 | 2024-07-16 | 44SS+15d | 3d | 0d |  | 260 días | 1.00 | 15,166.39 | 162 | m3 | 93.80 |
| 47 | 1.5.2.7 | GEOTEXTIL NO TEJIDO CLASE 1, INCLUYE INSTALACIÓN | 80d | 2023-10-13 | 2024-05-06 | 44SS | 78d |  |  | 207 días | 1.00 | 20,951.24 | 350 | m2 | 59.86 |
| 48 | 1.5.2.8 | RELLENO COMPACTADO CON MATERIAL PARA AFIRMADO EN CORONA | 70d | 2023-10-25 | 2024-05-10 | 44 | 74d |  |  | 199 días | 1.00 | 1,691.51 | 231 | m3 | 7.33 |
| 49 | 1.5.2.9 | RELLENO CON MATERIAL PROPIO | 10d | 2024-07-17 | 2024-07-27 | 46 | 8d |  |  | 11 días | 1.00 | 9,009.66 | 1,154 | m3 | 7.81 |
| 50 | 1.5.2.10 | RECUPERACIÓN DE ROCA EN DIQUES EXISTENTES | 55d | 2023-09-08 | 2023-11-11 | 43SS | 221d |  |  | 65 días | 1.00 | 10,620.45 | 200 | m3 | 53.10 |
| 51 | 1.5.3 | **TRANSPORTES DE MATERIAL** | 341d | 2023-06-20 | 2024-08-08 |  | 0d |  |  | 1 días |  |  |  |  |  |
| 52 | 1.5.3.1 | CARGUIO Y ACARREO DE MATERIAL PROPIO D≤1km | 220d | 2023-06-28 | 2024-07-12 | 14SS | 21d | 0d |  | 381 días | 1.00 | 224,454.29 | 1,385 | m3-km | 162.11 |
| 53 | 1.5.3.2 | CARGUIO Y ACARREO DE MATERIAL DE PRESTAMO D≤1km | 220d | 2023-06-28 | 2024-07-12 | 52SS | 21d | 0d |  | 381 días | 1.00 | 132,978.50 | 1,385 | m3-km | 96.04 |
| 54 | 1.5.3.3 | CARGUIO Y TRANSPORTE DE MATERIAL AFIRMADO D≤1KM | 145d | 2023-10-23 | 2024-08-08 | 36SS | 0d |  | start no earlier than 2023-10-22 | 291 días | 1.00 | 25,207.39 | 1,385 | m3-km | 18.21 |
| 55 | 1.5.3.4 | ACARREO DE MATERIAL PROPIO D>1km | 220d | 2023-06-28 | 2024-07-12 | 52SS | 21d |  |  | 381 días | 1.00 | 224,454.29 | 1,385 | m3-km | 162.11 |
| 56 | 1.5.3.5 | ACARREO DE MATERIAL DE PRESTAMO D>1Km | 220d | 2023-06-28 | 2024-07-12 | 53SS | 21d |  |  | 381 días | 1.00 | 132,978.50 | 1,385 | m3-km | 96.04 |
| 57 | 1.5.3.6 | TRANSPORTE DE MATERIAL AFIRMADO D>1KM | 145d | 2023-10-23 | 2024-08-08 | 54SS | 0d |  | start no earlier than 2023-10-22 | 291 días | 1.00 | 25,207.39 | 1,385 | m3-km | 18.21 |
| 58 | 1.5.3.7 | CARGUIO Y TRANSPORTE DE MATERIAL EXCEDENTE CON EQUIPO D≤ 1km | 220d | 2023-06-20 | 2024-07-06 | 19SS | 1d | 0d |  | 383 días | 1.00 | 216,859.74 | 1,385 | m3-km | 156.62 |
| 59 | 1.5.3.8 | TRANSPORTE DE MATERIAL EXCEDENTE CON EQUIPO D> 1km | 220d | 2023-06-20 | 2024-07-06 | 58SS | 26d |  |  | 383 días | 1.00 | 216,859.74 | 1,385 | m3-km | 156.62 |
| 60 | 1.5.3.9 | CARGUIO Y TRANSPORTE DE ROCA SELECCIONADA D≤1km | 221d | 2023-07-22 | 2024-08-08 | 27SS, 45FF | 0d |  |  | 384 días | 2.00 | 186,870.17 | 400 | m3-km | 233.59 |
| 61 | 1.5.3.10 | TRANSPORTE DE ROCA SELECCIONADA D >1km | 221d | 2023-07-22 | 2024-08-08 | 60SS | 0d |  |  | 384 días | 2.00 | 186,870.17 | 400 | m3-km | 233.59 |
| 62 | 1.6 | **COMPONENTE DE INTERFERENCIAS** | 319d | 2023-07-14 | 2024-08-06 |  | 2d |  |  | 1 días |  |  |  |  |  |
| 63 | 1.6.1 | **OBRAS DE RIEGO** | 319d | 2023-07-14 | 2024-08-06 |  | 2d |  |  | 1 días |  |  |  |  |  |
| 64 | 1.6.1.1 | CONSTRUCCION DE OBRAS DE RIEGO | 225d | 2023-07-14 | 2024-08-06 | 19SS+20d | 2d |  |  | 390 días | 1.00 | 14,590.19 | 1,077 | m3 | 13.55 |

| ID | WBS | Task | Type | Duration | Start | Finish | Predecessors | Total slack | Constraint | Dias Calendario | Metrado | Unidad | Frentes | Rendimiento diario | Duracion |
| --- | --- | --- | --- | --- | --- | --- | --- | --- | --- | --- | --- | --- | --- | --- | --- |
| 65 | 1.6.2 | **OBRAS DE REDES** |  | 5d | 2023-10-25 | 2023-10-30 |  | 231d |  | 1 días |  |  |  |  |  |
| 66 | 1.6.2.1 | REUBICACIÓN DE POSTE DE ENERGÍA |  | 5d | 2023-10-25 | 2023-10-30 | 44 | 231d |  | 6 días | 2.00 | und |  |  |  |
| 67 | 1.6.3 | **CRUCE VIAL** |  | 299d | 2023-08-09 | 2024-08-06 |  | 2d |  | 1 días |  |  |  |  |  |
| 68 | 1.6.3.1 | CONSTRUCCION DE OBRAS DE CRUCE VIAL |  | 205d | 2023-08-09 | 2024-08-06 | 24SS+20d | 2d |  | 364 días | 14,590.19 | m3 | 1.00 | 1,077 | 13.55 |
| 69 | 1.7 | **TRABAJOS DE CIERRE** |  | 20d | 2024-07-15 | 2024-08-08 |  | 0d |  | 1 días |  |  |  |  |  |
| 70 | 1.7.1 | MEDIDAS DE CONTINGENCIAS Y CIERRE DE OBRA |  | 20d | 2024-07-15 | 2024-08-08 | 39FF | 0d |  | 25 días | 1.00 | glb |  |  |  |
| 71 | 1.8 | **INFRAESTRUCTURA VERDE Y PAISAJISMO** |  | 65d | 2024-05-22 | 2024-08-08 |  | 0d |  | 1 días |  |  |  |  |  |
| 72 | 1.8.1 | INFRAESTRUCTURA VERDE Y PAISAJISMO |  | 65d | 2024-05-22 | 2024-08-08 | 70FF | 0d | finish no earlier than 2024-08-06 | 79 días |  |  |  |  |  |
| 73 | 1.8.2 | FIN DE EJECUCION HUARMEY PA | milestone | 0d | 2024-08-08 | 2024-08-08 | 70 | 0d |  | 0 días |  |  |  |  |  |
